# PROYECTO CONSTRUCCIÓN, MEJORAMIENTO Y REHABILITACIÓN DE LA CARRETERA CUSCO – CHINCHERO – URUBAMBA, EN LA REGIÓN CUSCO TRAMO 1

Schedule from MS Project, 2016-03-01 to 2016-12-25.

## Calendars

- Estándar: Mon-Sun 08:00-13:00, 14:00-17:00.

## Resources

| Resource | Group | Unit | Rate | Cost per use |
| --- | --- | --- | --- | --- |
| TOPOGRAFO | Mano de Obra |  | 14.34 |  |
| NIVELADOR | Mano de Obra |  | 14.34 |  |
| OPERARIO | Mano de Obra |  | 11.95 |  |
| OFICIAL | Mano de Obra |  | 10.69 |  |
| PEON | Mano de Obra |  | 9.66 |  |
| CAPATAZ "B" | Mano de Obra |  | 14.34 |  |
| CAPATAZ "A" | Mano de Obra |  | 15.54 |  |
| ALAMBRE NEGRO # 16 | Material | kg |  | 3.05 |
| ALAMBRE NEGRO # 8 | Material | kg |  | 3.05 |
| CLAVOS DIFERENTES MEDIDAS | Material | kg |  | 3.05 |
| PERNOS 3/8" X 8" + T + A | Material | pza |  | 2.53 |
| PERNOS 5/8" X 8" | Material | pza |  | 5.35 |
| ACERO CORRUGADO fy=4200 kg/cm2 GRADO 60 | Material | kg |  | 2.45 |
| LAMINA REFLECTIVA ALTA INTENSIDAD | Material | p2 |  | 12.89 |
| FILLER | Material | kg |  | 0.43 |
| ARENA DE SÍLICE | Material | m3 |  | 38.5 |
| ASFALTO LIQUIDO MC-30 | Material | gal |  | 7.2 |
| EMULSIÓN ASFÁLTICA | Material | gal |  | 6.22 |
| CEMENTO ASFALTICO MODIFICADO CON POLÍMEROS | Material | gal |  | 11.51 |
| CEMENTO PORTLAND TIPO I (42.5 kg) | Material | bls |  | 17.42 |
| YESO DE 28 Kg | Material | bls |  | 24.36 |
| SOLVENTE XILOL | Material | gal |  | 19.61 |
| THINNER STANDARD | Material | gal |  | 20.01 |
| PLANTAS NATIVAS | Material | kg |  | 60 |
| OXIGENO | Material | m3 |  | 18.51 |
| ACETILENO | Material | m3 |  | 48.17 |
| SOLDADURA (AWS E6011) | Material | kg |  | 8.33 |
| BARRENO 5' X 1/8" | Material | u |  | 311.69 |
| DESMOLDANTE PARA MADERA | Material | gal |  | 29.42 |
| MATERIAL DE RESPALDO PARA SELLADORES | Material |  |  | 5.15 |
| MASILLA PLASTICA BITUMINOSA | Material | kg |  | 5.57 |
| IMPRIMANTE ASFÁLTICO MODIFICADO | Material | kg |  | 20.98 |
| ACCESORIOS Y PEGAMENTO | Material | %MT |  |  |
| ADITIVO CURADOR | Material | gal |  | 16.92 |
| ADITIVO ADHESIVO EPÓXICO | Material | gal |  | 307.55 |
| FIBRA DE VIDRIO DE 4 mm ACABADO | Material | m2 |  | 127.69 |
| ADITIVO MEJORADOR DE ADHERENCIA | Material | kg |  | 16.92 |
| TINTA XEROGRÁFICA NEGRA | Material | gal |  | 1146.8 |
| TINTA XEROGRÁFICA ROJA | Material | gal |  | 1146.8 |
| GEOTEXTIL CLASE 2 | Material | m2 |  | 2.91 |
| TEKNOPOR DE 3/4" | Material | m2 |  | 1.9 |
| ESCOBILLA DE ACERO | Material | pza |  | 1.2 |
| WAYPE INDUSTRIAL | Material | kg |  | 4.34 |
| MADERA TORNILLO | Material | p2 |  | 3.98 |
| TRIPLAY DE 19 mm PARA ENCOFRADO | Material | pl |  | 90.63 |
| GAVION TIPO CAJA 10 X 12 CM 3.4 MM | Material | m3 |  | 81.48 |
| TEE DE ACERO LIVIANO DE 1 1/2" X 1 1/2" X 3/16" X 6 m | Material | pza |  | 53.04 |
| PLATINA DE ACERO 2" X 1/8" | Material |  |  | 4.22 |
| GUARDAVIA METALICA | Material |  |  | 42.94 |
| PERNO Y TUERCA DE GUARDAVIAS | Material | jgo |  | 21.01 |
| POSTE DE ACERO DE 1.80M X 6MM P/GUARDAVIA | Material | u |  | 88.34 |
| TERMINAL T-1 | Material | u |  | 40.58 |
| TERMINAL T-2 | Material | u |  | 60.85 |
| CAPTAFAROS | Material | u |  | 11.66 |
| POSTE DE ACERO DE 2.40M X 6MM P/GUARDAVIA | Material | u |  | 117.77 |
| PINTURA ANTICORROSIVA | Material | gal |  | 24.47 |
| PINTURA IMPRIMANTE | Material | gal |  | 15.08 |
| PINTURA ESMALTE | Material | gal |  | 28.64 |
| PINTURA PARA TRAFICO | Material | gal |  | 52.74 |
| MICROESFERAS DE VIDRIO | Material | kg |  | 4.81 |
| PINTURA WASH PRIMER | Material | gal |  | 146.32 |
| ACERO ESTRUCTURAL GRADO 36 | Material |  |  | 3100 |
| TUBO DE FIERRO NEGRO STD. Ø3" | Material |  |  | 36.73 |
| TUBERIA PVC SAP C-10 DE 2" | Material |  |  | 7.45 |
| TUBERIA PVC SAP C-10 DE 8" | Material |  |  | 86.93 |
| HERRAMIENTAS MANUALES | Equipo |  | 8 |  |
| JALONES | Equipo |  | 0.75 |  |
| MIRA TOPOGRAFICA | Equipo |  | 0.98 |  |
| MOTOSIERRA DE 30" | Equipo |  | 5.8 |  |
| EQUIPO DE PINTURA AIRLESS | Equipo |  | 25.49 |  |
| EQUIPO DE GRANALLADO | Equipo |  | 29.15 |  |
| MEZCLADORA DE CONCRETO DE 11p3 18 HP | Equipo |  | 41.04 |  |
| CAMION CISTERNA 4 X 2 (AGUA) 122 HP 2 000 gl | Equipo |  | 119.57 |  |
| CAMION VOLQUETE 15 m3 | Equipo |  | 190.18 |  |
| EQUIPO DE OXICORTE | Equipo |  | 2.51 |  |
| ENCOFRADO METALICO | Equipo |  | 8.25 |  |
| COMPRESORA NEUMATICA 250-330 PCM 87 HP | Equipo |  | 72.54 |  |
| COMPACTADOR VIBRATORIO TIPO PLANCHA 7 HP | Equipo |  | 23.48 |  |
| RODILLO LISO VIBRATORIO AUTOPROPULSADO 101-135HP 10-12 ton | Equipo |  | 100.54 |  |
| RODILLO LISO VIBRATORIO AUTOPROPULSADO 70-100 HP 7-9 ton | Equipo |  | 76.83 |  |
| RODILLO NEUMATICO AUTOPROPULSADO 135 HP 9-26 ton | Equipo |  | 88.29 |  |
| RODILLO NEUMATICO AUTOPROPULSADO 81-100HP 5.5-20 ton | Equipo |  | 71.31 |  |
| RODILLO TANDEM ESTATICO AUTOPROPULSADO 58-70HP 8-10 ton | Equipo |  | 53.2 |  |
| CARGADOR SOBRE LLANTAS 100-115 HP 2-2.25 yd3 | Equipo |  | 126.35 |  |
| CARGADOR SOBRE LLANTAS 200-250 HP 4-4.1 yd3 | Equipo |  | 221.76 |  |
| RETROEXCAVADOR SOBRE ORUGA 80-110HP 0.5-1.3 YD3 | Equipo |  | 160.92 |  |
| TRACTOR DE ORUGAS DE 190-240 HP | Equipo |  | 254.02 |  |
| TRACTOR SOBRE LLANTAS DE 200-250 HP | Equipo |  | 239.57 |  |
| BARREDORA MECANICA 10-20 HP 7 p LONGITUD | Equipo |  | 42.25 |  |
| CALENTADOR DE ACEITE 5 HP 468 p3 | Equipo |  | 44.13 |  |
| COCINA DE ASFALTO 320 gl | Equipo |  | 33.02 |  |
| SECADOR ARIDOS MOTOR EQUIPO 50 HP 30-65 ton/h | Equipo |  | 38.26 |  |
| FRESADORA DE PAVIMENTO RS-500B | Equipo |  | 475.5 |  |
| PAVIMENTADORA SOBRE ORUGAS 105 HP 10-16' | Equipo |  | 111.93 |  |
| CAMION GRAVILLADOR 11.8 M3 | Equipo |  | 253.6 |  |
| MARTILLO NEUMATICO DE 29 kg | Equipo |  | 24.02 |  |
| VIBRADOR DE CONCRETO 4 HP 1.50" | Equipo |  | 18.37 |  |
| MOTOSOLDADORA DE 225 A | Equipo |  | 27.6 |  |
| ZARANDA VIBRATORIA 4" X 6" X 14" MOTOR ELECTRICO 15 HP | Equipo |  | 33.8 |  |
| TRACTOR DE TIRO DE 80 HP | Equipo |  | 67.35 |  |
| CHANCADORA PRIMARIA SECUNDARIA 5 FAJAS 75 HP 46 - 70 ton/h | Equipo |  | 186.08 |  |
| MOTONIVELADORA DE 125 HP | Equipo |  | 131.11 |  |
| MOTONIVELADORA DE 145-150 HP | Equipo |  | 165.21 |  |
| CAMIONETA PICK UP 4 X 2 90 HP 2 ton | Equipo |  | 55.7 |  |
| GRUPO ELECTROGENO 116 HP 75 KW | Equipo |  | 58.3 |  |
| GRUPO ELECTROGENO 230 HP 150 KW | Equipo |  | 108.93 |  |
| FAJA TRANSPORTADORA 18" X 4' MOTOR ELECTRICO 3 KW 150 ton/h | Equipo |  | 25.93 |  |
| NIVEL TOPOGRAFICO | Equipo |  | 7.77 |  |
| MAQUINA PARA PINTAR MARCAS EN PAVIMENTO | Equipo |  | 45 |  |
| CORTADORA DE PAVIMENTO INCLUYE DISCO | Equipo |  | 35 |  |
| PLANTA DE ASFALTO DE 30/60 ton/h | Equipo |  | 57.36 |  |
| CAMION IMPRIMADOR DE 1800 gl | Equipo |  | 159.94 |  |
| GRUA HIAB SOBRE CAMION DE 5 ton | Equipo |  | 153.35 |  |
| TEODOLITO | Equipo |  | 9.62 |  |
| MOVILIZACIÓN Y DESMOVILIZACIÓN DE EQUIPOS | Subcontrato |  |  | 307748 |
| MANTENIMIENTO DE TRÁNSITO Y SEGURIDAD VIAL | Subcontrato |  |  | 402274 |
| SERVICIO DE SERIGRAFIA EN UN COLOR | Subcontrato |  |  | 7.88 |
| SERVICIO DE SERIGRAFIA EN DOS COLORES | Subcontrato |  |  | 30.29 |

## Schedule

| ID | WBS | Task | Type | Duration | Start | Finish | Predecessors | Total slack | Free slack | Constraint | Cost | Text1 | Text8 | Text3 | Text4 | Text6 |
| --- | --- | --- | --- | --- | --- | --- | --- | --- | --- | --- | --- | --- | --- | --- | --- | --- |
| 1 | 1 | INICIO DE OBRA | milestone | 0d | 2016-03-01 | 2016-03-01 |  | 0d |  | start no earlier than 2016-03-01 |  |  |  |  |  |  |
| 2 | 2 | **OBRAS PRELIMINARES** |  | 300d | 2016-03-01 | 2016-12-25 |  | 0d |  |  | 6,162,225.46 | 100 | 000000000000001 |  |  |  |
| 3 | 2.1 | MOVILIZACIÓN Y DESMOVILIZACIÓN DE EQUIPOS |  | 300d | 2016-03-01 | 2016-12-25 | 1SS | 0d |  | start no earlier than 2012-07-01 | 1,707,960.1 | 101.A | 000000000000002 | 307748.48 | 307748.48 |  |
| 4 | 2.2 | TRAZO Y REPLANTEO |  | 290d | 2016-03-04 | 2016-12-18 | 3SS+3d | 7d |  | start no earlier than 2013-05-26 | 193,334.03 | 102.B | 000000000000004 | 529.7 | 64729.34 | 2.5 |
| 5 | 2.3 | MANTENIMIENTO DE TRÁNSITO Y SEGURIDAD VIAL |  | 300d | 2016-03-01 | 2016-12-25 | 3SS | 0d |  |  | 3,803,803.85 | 103.A | 000000000000005 | 402273.87 | 402273.87 |  |
| 6 | 2.4 | ACCESOS A CANTERAS, DME, PLANTAS Y FUENTE DE AGUA |  | 180d | 2016-03-01 | 2016-08-27 |  | 180d |  | start no earlier than 2016-03-01 | 457,127.48 | 107.A |  |  |  |  |
| 7 | 3 | **MOVIMIENTO DE TIERRAS** |  | 290d | 2016-03-06 | 2016-12-20 |  | 5d |  |  | 28,384,010.48 | 200 |  |  |  |  |
| 8 | 3.1 | DESBROCE Y LIMPIEZA EN BOSQUE |  | 60d | 2016-03-06 | 2016-05-04 | 2SS+5d | 5d | 0d |  | 393,464.9 | 201.A |  |  |  |  |
| 9 | 3.2 | DESBROCE Y LIMPIEZA EN ZONAS NO BOSCOSAS |  | 40d | 2016-03-31 | 2016-05-09 | 3SS+30d | 230d |  |  | 50,817.73 | 201.B |  |  |  |  |
| 10 | 3.3 | EXCAVACIÓN EN ROCA FIJA |  | 180d | 2016-03-06 | 2016-09-01 | 11SS | 5d | 0d |  | 7,914,263.56 | 202.B1 |  |  |  |  |
| 11 | 3.4 | EXCAVACIÓN EN ROCA SUELTA |  | 180d | 2016-03-06 | 2016-09-01 | 12SS | 5d | 0d |  | 3,222,777.3 | 202.B2 |  |  |  |  |
| 12 | 3.5 | EXCAVACIÓN EN MATERIAL SUELTO |  | 180d | 2016-03-06 | 2016-09-01 | 8SS | 5d | 0d |  | 3,985,289.26 | 202.B3 |  |  |  |  |
| 13 | 3.6 | REMOCIÓN DE DERRUMBES |  | 260d | 2016-04-05 | 2016-12-20 | 10SS+30d | 5d | 0d |  | 262,903.03 | 203.A |  |  |  |  |
| 14 | 3.7 | CONFORMACION DE TERRAPLENES |  | 230d | 2016-04-20 | 2016-12-05 | 13SS+15d | 5d | 0d |  | 2,193,747.51 | 205.B |  |  |  |  |
| 15 | 3.8 | PERFILADO Y COMPACTADO EN ZONA DE CORTE |  | 160d | 2016-04-30 | 2016-10-06 | 14SS+10d | 80d |  |  | 1,311,313.82 | 210.A |  |  |  |  |
| 16 | 3.9 | MEJORAMIENTO DE SUELOS |  | 170d | 2016-05-05 | 2016-10-21 | 14SS+15d | 45d | 0d |  | 1,537,078.32 | 207.A |  |  |  |  |
| 17 | 3.10 | MATERIAL DE CANTERA PARA RELLENOS |  | 175d | 2016-05-20 | 2016-11-10 | 16SS+15d | 45d |  |  | 6,985,383.86 | 212.A |  |  |  |  |
| 18 | 3.11 | LAVADO DE MATERIAL GRANULAR |  | 100d | 2016-05-15 | 2016-08-22 | 34SS | 125d |  |  | 526,971.19 | 213.A |  |  |  |  |
| 19 | 4 | **PAVIMENTOS** |  | 230d | 2016-05-05 | 2016-12-20 |  | 5d |  |  | 68,007,566.83 | 400 |  |  |  |  |
| 20 | 4.1 | SUB BASE GRANULAR |  | 220d | 2016-05-05 | 2016-12-10 | 14SS+15d | 5d | 0d |  | 7,668,054.52 | 402.A |  |  |  |  |
| 21 | 4.2 | BASE GRANULAR |  | 200d | 2016-06-04 | 2016-12-20 | 20SS+30d | 5d | 0d |  | 11,705,965.4 | 403.A |  |  |  |  |
| 22 | 4.3 | IMPRIMACIÓN ASFÁLTICA |  | 70d | 2016-06-14 | 2016-08-22 | 21SS+10d | 5d | 0d |  | 775,911.74 | 416.A |  |  |  |  |
| 23 | 4.4 | CONCRETO ASFÁLTICO EN CALIENTE |  | 180d | 2016-06-24 | 2016-12-20 | 22FS-60d | 5d | 0d |  | 19,158,150.16 | 423.C |  |  |  |  |
| 24 | 4.5 | CEMENTO ASFÁLTICO DE PENETRACION 120-150 |  | 180d | 2016-06-24 | 2016-12-20 | 23SS | 5d |  |  | 20,399,488.86 | 426.B |  |  |  |  |
| 25 | 4.6 | ASFALTO DILUIDO TIPO MC-30 |  | 180d | 2016-06-24 | 2016-12-20 | 23SS | 5d |  |  | 2,148,678.67 | 428.A |  |  |  |  |
| 26 | 4.7 | FILLER MINERAL |  | 180d | 2016-06-24 | 2016-12-20 | 23SS | 5d |  |  | 4,482,353.12 | 429.A |  |  |  |  |
| 27 | 4.8 | ADITIVO MEJORADOR DE ADHERENCIA |  | 180d | 2016-06-24 | 2016-12-20 | 23SS | 5d |  |  | 1,668,964.36 | 430.A |  |  |  |  |

| ID | WBS | Task | Duration | Start | Finish | Predecessors | Total slack | Free slack | Constraint | Cost | Text1 |
| --- | --- | --- | --- | --- | --- | --- | --- | --- | --- | --- | --- |
| 28 | 5 | **DRENAJE** | 235d | 2016-04-30 | 2016-12-20 |  | 5d |  |  | 75,030,203.12 | 500 |
| 29 | 5.1 | EXCAVACION NO CLASIFICADA PARA ESTRUCTURAS | 180d | 2016-04-30 | 2016-10-26 | 3SS+60d | 5d | 0d |  | 7,214,907.25 | 501.E |
| 30 | 5.2 | RELLENOS PARA ESTRUCTURAS | 120d | 2016-05-10 | 2016-09-06 | 29SS+10d | 57d | 0d |  | 7,745,822.66 | 502.A |
| 31 | 5.3 | RELLENO PARA SUELO REFORZADO | 40d | 2016-09-07 | 2016-10-16 | 30 | 57d | 0d |  | 304,538.48 | 502.B |
| 32 | 5.4 | MATERIAL IMPERMEABLE | 13d | 2016-10-17 | 2016-10-29 | 31 | 57d |  |  | 27,228.86 | 502.D |
| 33 | 5.5 | CONCRETO CLASE C (F'C = 280 KG/CM2) | 30d | 2016-05-30 | 2016-06-28 | 29SS+30d | 130d | 85d |  | 1,464,924.87 | 503.C |
| 34 | 5.6 | CONCRETO CLASE D (F'C = 210 KG/CM2) | 180d | 2016-05-15 | 2016-11-10 | 29SS+15d | 5d | 0d |  | 9,490,682.15 | 503.D1 |
| 35 | 5.7 | CONCRETO CLASE E (F'C = 175 KG/CM2) | 100d | 2016-07-14 | 2016-10-21 | 34SS+60d | 65d | 20d |  | 2,793,472.21 | 503.E |
| 36 | 5.8 | CONCRETO CLASE G (F'C = 140 KG/CM2 + 30%PM) | 100d | 2016-07-14 | 2016-10-21 | 34SS+60d | 5d | 0d |  | 415,497.02 | 503.G1 |
| 37 | 5.9 | CONCRETO CLASE H (F'C = 100 KG/CM2) | 100d | 2016-07-14 | 2016-10-21 | 34SS+60d | 65d |  |  | 2,149,398.3 | 503.H |
| 38 | 5.10 | ACERO DE REFUERZO FY=4200KG/CM2 | 150d | 2016-07-14 | 2016-12-10 | 36SS | 5d | 0d |  | 8,171,569.22 | 504.A |
| 39 | 5.11 | TUBERÍA METALICA CORRUGADA CIRCULAR DE 1.20 M DE DIÁMETRO | 70d | 2016-07-04 | 2016-09-11 | 61 | 105d |  |  | 1,897,900.75 | 507.A3 |
| 40 | 5.12 | TUBERÍA METALICA CORRUGADA CIRCULAR DE 1.50 M DE DIÁMETRO | 80d | 2016-08-23 | 2016-11-10 | 51SS+10d | 25d | 0d |  | 778,385.31 | 507.A4 |
| 41 | 5.13 | TUBERIA METALICA CORRUGADA CIRCULAR DE 1.80 M DE DIAMETRO | 70d | 2016-09-22 | 2016-11-30 | 40SS+30d | 25d |  | start no earlier than 2016-09-04 | 918,331.21 | 507.A5 |
| 42 | 5.14 | CUNETA TRIANGULAR REVESTIDA | 100d | 2016-08-23 | 2016-11-30 | 40SS | 25d | 0d |  | 8,371,398.86 | 510.A |
| 43 | 5.15 | CUNETA RECTANGULAR REVESTIDA | 80d | 2016-08-23 | 2016-11-10 | 51SS+10d | 45d |  |  | 6,513,854.08 | 510.C |
| 44 | 5.16 | CUNETA RECTANGULAR REVESTIDA TIPO II | 80d | 2016-08-23 | 2016-11-10 | 51SS+10d | 45d |  |  | 6,513,854.08 | 510.C2 |
| 45 | 5.17 | ZANJA DE DRENAJE | 70d | 2016-08-23 | 2016-10-31 | 51SS+10d | 55d |  |  | 42,007.94 | 510.D |
| 46 | 5.18 | ZANJA REVESTIDA EN DME | 70d | 2016-08-23 | 2016-10-31 | 51SS+10d | 55d |  |  | 1,656,830.54 | 510.E |
| 47 | 5.19 | CUNETA TRIANGULAR REVESTIDA EN DME | 70d | 2016-08-23 | 2016-10-31 | 51SS+10d | 55d |  |  | 497,164.08 | 510.F |
| 48 | 5.20 | GEOTEXTIL NO TEJIDO CLASE 2 | 70d | 2016-09-12 | 2016-11-20 | 38SS+60d | 35d |  |  | 880,519.35 | 511.C |
| 49 | 5.21 | TUBO DE PVC-SAP , D=2" | 145d | 2016-07-14 | 2016-12-05 | 38SS | 5d | 0d |  | 7,217.41 | 515.B |
| 50 | 5.22 | TUBO DE PVC-SAP , D=3" | 145d | 2016-07-14 | 2016-12-05 | 49SS | 5d | 0d |  | 191,369.49 | 515.C |
| 51 | 5.23 | TUBO DE PVC-SAP, D=6" | 130d | 2016-08-13 | 2016-12-20 | 50SS+30d | 5d | 0d |  | 3,687,334.56 | 515.E |
| 52 | 5.24 | TUBERÍA DE VENTILACIÓN F°G° D =1 1/2" | 30d | 2016-08-13 | 2016-09-11 | 51SS | 105d |  |  | 15,574.79 | 516.A |
| 53 | 5.25 | FILTRO DRENANTE | 20d | 2016-08-23 | 2016-09-11 | 42SS | 105d |  |  | 2,449,830.92 | 517.D |
| 54 | 5.26 | GEOCOMPUESTO DE DRENAJE | 40d | 2016-09-07 | 2016-10-16 | 31SS | 70d |  |  | 67,497.43 | 518.A |
| 55 | 5.27 | BORDILLO | 60d | 2016-08-23 | 2016-10-21 | 42SS | 65d |  |  | 284,364.27 | 527.A |
| 56 | 5.28 | GEOMALLA DE REFUERZO - 37.5 KN/m | 40d | 2016-09-07 | 2016-10-16 | 31SS | 70d |  |  | 99,457.93 | 528.A |
| 57 | 5.29 | GEOMALLA DE REFUERZO - 50 KN/m | 40d | 2016-09-07 | 2016-10-16 | 31SS | 70d |  |  | 160,085.7 | 528.B |
| 58 | 5.30 | GEOMALLA DE REFUERZO - 65 KN/m | 40d | 2016-09-07 | 2016-10-16 | 31SS | 70d |  |  | 154,513.18 | 528.C |
| 59 | 5.31 | PANELES PREFABRICADOS PARA TIERRA ARMADA | 40d | 2016-09-07 | 2016-10-16 | 31SS | 70d |  |  | 19,583.12 | 529.A |
| 60 | 5.32 | ELIMINACION DE ALCANTARILLAS TMC EXISTENTES | 30d | 2016-05-15 | 2016-06-13 | 29SS+15d | 105d | 0d |  | 6,159.82 | 536.A |
| 61 | 5.33 | ENCAUZAMIENTO PARA ALCANTARILLAS | 40d | 2016-05-25 | 2016-07-03 | 60SS+10d | 105d | 0d |  | 38,927.28 | 540.A |

| ID | WBS | Task | Duration | Start | Finish | Predecessors | Total slack | Free slack | Constraint | Cost | Text1 |
| --- | --- | --- | --- | --- | --- | --- | --- | --- | --- | --- | --- |
| 62 | 6 | **OBRAS COMPLEMENTARIAS** | 120d | 2016-08-23 | 2016-12-20 | 51SS+10d | 5d |  |  | 13,553,774.54 | 600 |
| 63 | 6.1 | EMBOQUILLADO DE PIEDRA | 80d | 2016-08-23 | 2016-11-10 | 35SS+20d | 45d |  |  | 3,884,007.46 | 601.B |
| 64 | 6.2 | DEMOLICIÓN DE ESTRUCTURAS | 80d | 2016-08-23 | 2016-11-10 | 51SS+10d | 25d | 0d |  | 372,004.08 | 604.H |
| 65 | 6.3 | SARDINEL PERALTADO | 20d | 2016-11-11 | 2016-11-30 | 64 | 25d | 0d | finish no earlier than 2016-06-28 | 654,729.44 | 606.A |
| 66 | 6.4 | CRUCE PEATONAL | 40d | 2016-08-23 | 2016-10-01 | 33SS | 45d | 0d |  | 102,562.38 | 607.A |
| 67 | 6.5 | CRUCE VEHICULAR | 40d | 2016-10-02 | 2016-11-10 | 66 | 45d |  |  | 734,130.72 | 608.A |
| 68 | 6.6 | VEREDAS e=4" | 80d | 2016-08-23 | 2016-11-10 |  | 45d |  |  | 1,634,280.58 | 610.A |
| 69 | 6.7 | ENCOFRADO Y DESENCOFRADO | 40d | 2016-11-11 | 2016-12-20 | 65SS | 5d |  |  | 6,121,639.35 | 612.A |
| 70 | 6.8 | JUNTA PARA MUROS | 90d | 2016-08-23 | 2016-11-20 | 34SS+20d | 35d |  |  | 50,420.53 | 617.A |
| 71 | 7 | **TRANSPORTE** | 290d | 2016-03-06 | 2016-12-20 |  | 5d |  |  | 72,409,918.59 | 700 |
| 72 | 7.1 | TRANSPORTE DE MATERIAL GRANULAR PARA DISTANCIAS ENTRE 120 M Y 1000 M | 230d | 2016-05-05 | 2016-12-20 | 14SS+15d | 5d | 0d |  | 8,811,736.45 | 700.A |
| 73 | 7.2 | TRANSPORTE DE MATERIAL GRANULAR PARA DISTANCIAS MAYORES DE 1000 M | 230d | 2016-05-05 | 2016-12-20 | 72SS | 5d |  |  | 28,456,471.65 | 700.B |
| 74 | 7.3 | TRANSPORTE DE MATERIALES EXCEDENTES PARA DISTANCIAS ENTRE 120 M Y 1000 M | 290d | 2016-03-06 | 2016-12-20 | 10SS | 5d |  | start no earlier than 2016-03-01 | 11,953,954.73 | 700.C |
| 75 | 7.4 | TRANSPORTE DE MATERIALES EXCEDENTES PARA DISTANCIAS MAYORES DE 1000 M | 290d | 2016-03-06 | 2016-12-20 | 10SS | 5d |  | start no earlier than 2016-03-01 | 20,960,277.72 | 700.D |
| 76 | 7.5 | TRANSPORTE DE MEZCLAS ASFALTICAS PARA DISTANCIAS HASTA 1000 M | 180d | 2016-06-24 | 2016-12-20 | 23SS | 5d |  |  | 840,693.84 | 700.E |
| 77 | 7.6 | TRANSPORTE DE MEZCLAS ASFALTICAS PARA DISTANCIAS MAYORES DE 1000 M | 180d | 2016-06-24 | 2016-12-20 | 23SS | 5d |  |  | 1,338,257.34 | 700.F |
| 78 | 7.7 | TRANSPORTE DE MATERIAL DE DERRUMBES A DME PARA D> 1KM | 260d | 2016-04-05 | 2016-12-20 | 13SS | 5d |  | start no earlier than 2016-03-01 | 48,526.86 | 700.I |
| 79 | 8 | **SEÑALIZACION Y SEGURIDAD VIAL** | 30d | 2016-11-26 | 2016-12-25 |  | 0d |  |  | 5,355,467.03 | 800 |
| 80 | 8.1 | SEÑALES PREVENTIVAS 0.60 x 0.60 m. | 20d | 2016-12-06 | 2016-12-25 | 109FF | 0d |  | start no earlier than 2016-11-02 | 61,863.39 | 801.B |
| 81 | 8.2 | SEÑALES PREVENTIVAS 0.75 m x 0.75 m. | 20d | 2016-12-06 | 2016-12-25 | 109FF | 0d |  |  | 282,612 | 801.C |
| 82 | 8.3 | SEÑAL REGLAMENTARIA OCTOGONAL 0.60m x 0.60m | 20d | 2016-12-06 | 2016-12-25 | 109FF | 0d |  |  | 4,968.08 | 802.B |
| 83 | 8.4 | SEÑALES REGLAMENTARIAS 1.20 m x 0.80 m. | 20d | 2016-12-06 | 2016-12-25 | 109FF | 0d |  |  | 187,460.64 | 802.E |
| 84 | 8.5 | SEÑALES INFORMATIVAS | 20d | 2016-12-06 | 2016-12-25 | 109FF | 0d |  |  | 79,376.39 | 803.A |
| 85 | 8.6 | SEÑALES INFORMATIVAS DE SERVICIOS AUXILIARES 0.60m x 0.50m | 20d | 2016-12-06 | 2016-12-25 | 109FF | 0d |  |  | 13,432.8 | 803.C |
| 86 | 8.7 | MARCAS EN EL PAVIMENTO | 20d | 2016-12-06 | 2016-12-25 | 109FF | 0d |  |  | 293,435.74 | 805.A |
| 87 | 8.8 | BARRERA DE SEGURIDAD LATERAL NIVEL DE CONTENCION P3 | 20d | 2016-12-06 | 2016-12-25 | 109FF | 0d |  |  | 3,871,777.02 | 806.C |
| 88 | 8.9 | POSTE DE KILOMETRAJE | 10d | 2016-12-16 | 2016-12-25 | 109FF | 0d |  |  | 12,738.6 | 810.A |
| 89 | 8.10 | ESTRUCTURA DE SOPORTE DE SEÑALES TIPO E-1 | 20d | 2016-12-06 | 2016-12-25 | 109FF | 0d |  |  | 113,062.3 | 811.C |
| 90 | 8.11 | GIBAS O RESALTO | 20d | 2016-12-06 | 2016-12-25 | 109FF | 0d |  |  | 144,707.27 | 818.A |
| 91 | 8.12 | MÓDULO PARADERO | 30d | 2016-11-26 | 2016-12-25 | 109FF | 0d |  |  | 290,032.8 | 819.A |

| ID | WBS | Task | Duration | Start | Finish | Predecessors | Total slack | Free slack | Constraint | Cost | Text1 |
| --- | --- | --- | --- | --- | --- | --- | --- | --- | --- | --- | --- |
| 92 | 9 | **PROTECCIÓN AMBIENTAL** | 300d | 2016-03-01 | 2016-12-25 |  | 0d |  |  | 13,720,712.46 | 900 |
| 93 | 9.1 | **PROGRAMA DE ABANDONO Y CIERRE DE OBRA** | 300d | 2016-03-01 | 2016-12-25 |  | 0d |  |  | 8,043,634.61 | 900.A1 |
| 94 | 9.1.1 | READECUACION AMBIENTAL DE CANTERAS DE RIO | 80d | 2016-10-07 | 2016-12-25 | 109FF | 0d |  | start no earlier than 2011-09-11 | 700,678.91 | 906.B |
| 95 | 9.1.2 | READECUACION AMBIENTAL DE CANTERAS DE CERRO | 80d | 2016-10-07 | 2016-12-25 | 109FF | 0d |  | start no earlier than 2014-06-06 | 178,406.38 | 906.C |
| 96 | 9.1.3 | READECUACION AMBIENTAL DE PLANTAS DE TRITURACION, ASFALTO Y CONCRETO | 70d | 2016-10-17 | 2016-12-25 | 109FF | 0d |  |  | 13,524 | 906.D |
| 97 | 9.1.4 | READECUACION AMBIENTAL DEL CAMPAMENTO | 20d | 2016-12-06 | 2016-12-25 | 109FF | 0d |  |  | 20,307.61 | 906.E |
| 98 | 9.1.5 | READECUACION AMBIENTAL DEL PATIO DE MAQUINAS Y POLVORIN | 20d | 2016-12-06 | 2016-12-25 | 109FF | 0d |  |  | 23,648.95 | 906.F |
| 99 | 9.1.6 | DISPOSICION Y CONFORMACION DE MATERIAL EXCEDENTE | 300d | 2016-03-01 | 2016-12-25 | 100SS | 0d |  |  | 5,056,402.68 | 908.A |
| 100 | 9.1.7 | RETIRO Y ALMACENAMIENTO DE TOP SOIL | 300d | 2016-03-01 | 2016-12-25 | 3SS | 0d |  |  | 991,155.27 | 914.A |
| 101 | 9.1.8 | REPOSICIÓN DE TOP SOIL | 300d | 2016-03-01 | 2016-12-25 |  | 0d |  | start no earlier than 2016-03-01 | 722,615.67 | 914.B |
| 102 | 9.1.9 | REVEGETACIÓN DE AREAS AUXILIARES | 80d | 2016-10-07 | 2016-12-25 | 109FF | 0d |  |  | 336,895.14 | 918.A |
| 103 | 9.2 | **SUBPROGRAMA DE COMPENSACIÓN POR USO DE ÁREAS AUXILIARES** | 200d | 2016-03-01 | 2016-09-16 |  | 100d |  |  | 1,591,124.4 | 900.A2 |
| 104 | 9.2.1 | PAGO POR MATERIAL DE CANTERA POR CONCESIÓN | 200d | 2016-03-01 | 2016-09-16 | 3SS | 100d |  |  | 1,591,124.4 | 919.B |
| 105 | 9.3 | **SUBPROGRAMA DE SEÑALIZACION AMBIENTAL** | 40d | 2016-11-16 | 2016-12-25 |  | 0d |  |  | 149,940.85 | 910 |
| 106 | 9.3.1 | SEÑAL INFORMATIVA AMBIENTAL | 40d | 2016-11-16 | 2016-12-25 | 109FF | 0d |  |  | 83,842.89 | 911.A |
| 107 | 9.3.2 | ESTRUCTURA DE SOPORTE DE SEÑALES TIPO E-1 | 40d | 2016-11-16 | 2016-12-25 | 106SS | 0d |  |  | 66,097.96 | 912.A |
| 108 | 9.4 | **PROGRAMA DE MONITOREO AMBIENTAL** | 300d | 2016-03-01 | 2016-12-25 |  | 0d |  |  | 3,936,012.6 | 970 |
| 109 | 9.4.1 | MONITOREO DE CALIDAD DE AGUA, AIRE, RUIDO Y SUELOS | 300d | 2016-03-01 | 2016-12-25 | 3SS | 0d |  | start no earlier than 2014-05-01 | 2,703,896 | 970.A |
| 110 | 9.4.2 | MONITOREO HIDROBIOLÓGICO | 300d | 2016-03-01 | 2016-12-25 | 3SS | 0d |  | start no earlier than 2014-05-01 | 639,719.6 | 970.B |
| 111 | 9.4.3 | MONITOREO BIOLÓGICO | 300d | 2016-03-01 | 2016-12-25 | 3SS | 0d |  | start no earlier than 2014-05-01 | 592,397 | 970.C |
| 112 | 10 | **INTERCAMBIOS VIALES** | 240d | 2016-03-31 | 2016-11-25 |  | 30d |  |  | 745,339.95 | 1110 |
| 113 | 10.1 | INTERCAMBIO AEROPUERTO | 210d | 2016-03-31 | 2016-10-26 | 1SS+30d | 30d | 0d | start no earlier than 2016-01-31 | 86,971.04 | 1110.1 |
| 114 | 10.2 | INTERCAMBIO RAQCHI | 90d | 2016-08-28 | 2016-11-25 | 113FS-60d | 90d |  |  | 658,368.91 | 1120.1 |
